# Zwembad plaatsen – Jodoigne – Rue des anges 14

Schedule from MS Project, 2025-05-05 to 2025-07-03, costs in €.
VDAB

## Calendars

- Standaard: Mon-Fri 08:00-12:00, 13:00-17:00; Sat-Sun off. Exceptions (off unless hours are given): 2025-05-29 to 2025-05-30 (OHV), 2025-06-09 (Pinkstermaandag).

## Resources

| Resource | Unit | Rate | Cost per use |
| --- | --- | --- | --- |
| Werfleider |  | 40 |  |
| Architect |  |  |  |
| Arbeiders |  | 25 |  |
| Graafmachine |  | 62.5 | 300 |
| Beton | m³ | 40 |  |
| Andere materialen |  |  |  |
| Administratieve medewerk(st)er |  | 30 |  |
| Loodgieter |  |  |  |

## Schedule

| ID | WBS | Task | Type | Duration | Start | Finish | Predecessors | Total slack | Free slack | Resources | Work | Cost |
| --- | --- | --- | --- | --- | --- | --- | --- | --- | --- | --- | --- | --- |
| 1 | 1 | **Voorbereiding** |  | 18.5d | 2025-05-05 | 2025-06-02 |  | 0d |  |  | 27h | 720 |
| 2 | 1.1 | Concept - klant ontmoeten |  | 1w | 2025-05-05 | 2025-05-09 |  | 7.12d | 0d | Werfleider | 3h | 120 |
| 3 | 1.2 | Analyse van de leidingen |  | 1d | 2025-05-09 | 2025-05-09 | 2FF | 7.12d | 0d | Architect [0.1%] |  |  |
| 4 | 1.3 | Werf voorbereiden |  | 1d | 2025-05-28 | 2025-06-02 | 10 | 0d |  | Arbeiders [300%] | 24h | 600 |
| 5 | 1.4 | Voorschot ontvangen | milestone, manual | 0d | 2025-05-15 | 2025-05-15 | 3 |  |  |  |  |  |
| 6 | 2 | **Ontwerpfase** |  | 17.5d | 2025-05-05 | 2025-05-28 |  | 0d |  |  | 3h | 3,090 |
| 7 | 2.1 | Opmeten |  | 2d | 2025-05-12 | 2025-05-13 | 3 | 7.12d | 0d | Architect [0.1%] |  |  |
| 8 | 2.2 | Plan tekenen |  | 1d | 2025-05-14 | 2025-05-14 | 7 | 7.12d | 2d | Architect [0.1%] |  | 3,000 |
| 9 | 2.3 | Vergunning aanvragen |  | 2w | 2025-05-05 | 2025-05-28 |  | 0d |  | Administratieve medewerk(st)er | 3h | 90 |
| 10 | 2.4 | Go / nogo | milestone | 0d | 2025-05-28 | 2025-05-28 | 9, 5 | 0d |  |  |  |  |
| 11 | 3 | **Bestellingen** |  | 7.38d | 2025-05-19 | 2025-05-28 |  | 3.12d |  |  | 9h | 270 |
| 12 | 3.1 | Offertes aanvragen |  | 3d | 2025-05-19 | 2025-05-26 | 8 | 3.12d | 0d | Administratieve medewerk(st)er | 4h | 120 |
| 13 | 3.2 | Bestellen van ijzer, hout, tegels, … |  | 0.25w | 2025-05-20 | 2025-05-26 | 14FF-2d | 5.12d |  | Administratieve medewerk(st)er [20%] | 2h | 60 |
| 14 | 3.3 | Bestellen van de pompen |  | 0.38w | 2025-05-26 | 2025-05-28 | 12 | 3.12d | 0d | Administratieve medewerk(st)er [20%] | 3h | 90 |
| 15 | 4 | **Graafwerken** |  | 2.5d | 2025-06-02 | 2025-06-04 |  | 0d |  |  | 51h | 2,670 |
| 16 | 4.1 | Uitgraven van de zwembad zone |  | 1d | 2025-06-02 | 2025-06-03 | 4 | 0d |  | Arbeiders [300%]; Graafmachine; Werfleider | 35h | 1,520 |
| 17 | 4.2 | Afvoeren van de aarde |  | 1d | 2025-06-03 | 2025-06-04 | 16 | 0d |  | Arbeiders [200%] | 16h | 400 |
| 18 | 4.3 | Uitgraven ivm technische ruimte |  | 0.5d | 2025-06-04 | 2025-06-04 | 17 | 0d |  | Arbeiders [200%]; Graafmachine | 12h | 750 |
| 19 | 5 | **Werkvloer** |  | 1d | 2025-06-05 | 2025-06-05 | 15, 11 | 0d |  |  | 56h | 1,600 |
| 20 | 5.1 | Afvoerbuizen plaatsen |  | 1d | 2025-06-05 | 2025-06-05 |  | 19d |  | Arbeiders [200%] | 16h | 400 |
| 21 | 5.2 | Dichtingen uitvoeren |  | 1d | 2025-06-05 | 2025-06-05 |  | 19d |  | Arbeiders [200%] | 16h | 400 |
| 22 | 5.3 | Beton gieten |  | 1d | 2025-06-05 | 2025-06-05 |  | 0d |  | Arbeiders [300%]; Beton [5 m³] | 24h | 800 |
| 23 | 6 | **Installatie van het zwembad** |  | 14.5d | 2025-06-10 | 2025-06-30 |  | 0d |  | Andere materialen [0.1%] | 88h | 18,000 |
| 24 | 6.1 | Bekisting aanbrengen |  | 2d | 2025-06-10 | 2025-06-11 | 22FS+1d | 0d |  | Arbeiders [250%] | 40h | 1,000 |
| 25 | 6.2 | Betonneren |  | 2d | 2025-06-12 | 2025-06-13 | 24 | 0d |  | Arbeiders [300%]; Beton [1.25 m³] | 48h | 2,000 |
| 26 | 6.3 | Ontkisten |  | 1.5d | 2025-06-16 | 2025-06-17 | 25 | 0d |  |  |  |  |
| 27 | 6.4 | Poolhouse plaatsen |  | 2d | 2025-06-12 | 2025-06-13 | 25SS | 12d | 0d |  |  |  |
| 28 | 6.5 | Pompen en leidingen installeren |  | 4d | 2025-06-16 | 2025-06-19 | 27 | 10d |  | Loodgieter [0.1%] |  | 5,000 |
| 29 | 6.6 | Tegels plaatsen |  | 4d | 2025-06-24 | 2025-06-30 | 26FS+1w | 0d |  |  |  |  |

Notes:
- 5: zou een vb kunnen zijn van manuele taak
- 8: Volledige kost voor architect
- 19: vb van links tussen overzichtstaken
- 22: Droogtijd 1d extra
- 25: gelijk begin

| ID | WBS | Task | Type | Duration | Start | Finish | Predecessors | Total slack | Deadline |
| --- | --- | --- | --- | --- | --- | --- | --- | --- | --- |
| 30 | 7 | **Afwerken** |  | 3.5d | 2025-06-30 | 2025-07-03 |  | 0d |  |
| 31 | 7.1 | Voegen |  | 1.5d | 2025-06-30 | 2025-07-01 | 29 | 0d |  |
| 32 | 7.2 | Aanvullingen rond zwembad |  | 1d | 2025-07-02 | 2025-07-02 | 31 | 1d |  |
| 33 | 7.3 | graszoden plaatsen |  | 1d | 2025-07-02 | 2025-07-02 | 31 | 1d |  |
| 34 | 7.4 | Vullen met water |  | 1d | 2025-07-02 | 2025-07-02 | 31 | 0d |  |
| 35 | 7.5 | Testen |  | 1d | 2025-07-03 | 2025-07-03 | 34 | 0d |  |
| 36 | 8 | Oplevering | milestone | 0d | 2025-07-03 | 2025-07-03 | 35 | 0d | 2025-07-11 |
