# Zwembad plaatsen – Jodoigne – Rue des anges 14

Schedule from MS Project, 2025-05-05 to 2025-07-07, costs in €, A marks actual dates.
VDAB

## Calendars

- Standaard: Mon-Fri 08:00-12:00, 13:00-17:00; Sat-Sun off. Exceptions (off unless hours are given): 2025-05-29 to 2025-05-30 (OHV), 2025-06-09 (Pinkstermaandag).

## Resources

| Resource | Unit | Rate | Cost per use |
| --- | --- | --- | --- |
| Werfleider |  | 40 |  |
| Architect |  |  |  |
| Arbeiders |  | 25 |  |
| Graafmachine |  | 62.5 | 300 |
| Beton | m³ | 40 |  |
| Andere materialen |  |  |  |
| Administratieve medewerk(st)er |  | 30 |  |
| Loodgieter |  |  |  |

## Schedule

| ID | WBS | Task | Type | Duration | Start | Finish | Predecessors | Complete | Remaining | Baseline start | Baseline finish | Baseline duration | Total slack | Free slack | Resources | Work | Actual work | Cost | Baseline cost | Actual cost |
| --- | --- | --- | --- | --- | --- | --- | --- | --- | --- | --- | --- | --- | --- | --- | --- | --- | --- | --- | --- | --- |
| 1 | 1 | **Voorbereiding** |  | 21d | 2025-05-05 A | 2025-06-04 A |  | 100% |  | 2025-05-05 | 2025-06-02 | 18.5d |  |  |  | 23h | 23h | 620 | 720 | 620 |
| 2 | 1.1 | Concept - klant ontmoeten |  | 1w | 2025-05-05 A | 2025-05-09 A |  | 100% |  | 2025-05-05 | 2025-05-09 | 1w |  |  | Werfleider | 3h | 3h | 120 | 120 | 120 |
| 3 | 1.2 | Analyse van de leidingen |  | 1d | 2025-05-14 A | 2025-05-14 A | 2FF | 100% |  | 2025-05-09 | 2025-05-09 | 1d |  |  | Architect [0.1%] |  |  |  |  |  |
| 4 | 1.3 | Werf voorbereiden |  | 2d | 2025-06-03 A | 2025-06-04 A | 10 | 100% |  | 2025-05-28 | 2025-06-02 | 1d |  |  | Arbeiders [300%] | 20h | 20h | 500 | 600 | 500 |
| 5 | 1.4 | Voorschot ontvangen | milestone, manual | 0d | 2025-05-20 A | 2025-05-20 A | 3 | 100% |  | 2025-05-15 | 2025-05-15 | 0d |  |  |  |  |  |  |  |  |
| 6 | 2 | **Ontwerpfase** |  | 18d | 2025-05-05 A | 2025-05-30 A |  | 100% |  | 2025-05-05 | 2025-05-28 | 17.5d |  |  |  | 6h | 6h | 3,680 | 3,090 | 3,680 |
| 7 | 2.1 | Opmeten |  | 3d | 2025-05-19 A | 2025-05-21 A | 3 | 100% |  | 2025-05-12 | 2025-05-13 | 2d |  |  | Architect [0.1%] |  |  |  |  |  |
| 8 | 2.2 | Plan tekenen |  | 5d | 2025-05-22 A | 2025-05-28 A | 7 | 100% |  | 2025-05-14 | 2025-05-14 | 1d |  |  | Architect [0.1%] |  |  | 3,500 | 3,000 | 3,500 |
| 9 | 2.3 | Vergunning aanvragen |  | 3.5w | 2025-05-05 A | 2025-05-28 A |  | 100% |  | 2025-05-05 | 2025-05-28 | 2w |  |  | Administratieve medewerk(st)er | 6h | 6h | 180 | 90 | 180 |
| 10 | 2.4 | Go / nogo | milestone | 0d | 2025-05-30 A | 2025-05-30 A | 9, 5, 8 | 100% |  | 2025-05-28 | 2025-05-28 | 0d |  |  |  |  |  |  |  |  |
| 11 | 3 | **Bestellingen** |  | 6.5d | 2025-06-02 A | 2025-06-11 |  | 38% | 4.02d | 2025-05-19 | 2025-05-28 | 7.38d | 0d |  |  | 8.53h | 3.33h | 256 | 270 | 100 |
| 12 | 3.1 | Offertes aanvragen |  | 2d | 2025-06-02 A | 2025-06-03 A | 8 | 100% |  | 2025-05-19 | 2025-05-26 | 3d |  |  | Administratieve medewerk(st)er | 3.33h | 3.33h | 100 | 120 | 100 |
| 13 | 3.2 | Bestellen van ijzer, hout, tegels, … |  | 0.25w | 2025-06-03 | 2025-06-06 | 14FF-2d |  |  | 2025-05-20 | 2025-05-26 | 0.25w | 2d |  | Administratieve medewerk(st)er [20%] | 2h |  | 60 | 60 |  |
| 14 | 3.3 | Bestellen van de pompen |  | 2d | 2025-06-04 | 2025-06-11 | 12 |  |  | 2025-05-26 | 2025-05-28 | 0.38w | 0d |  | Administratieve medewerk(st)er [20%] | 3.2h |  | 96 | 90 |  |
| 15 | 4 | **Graafwerken** |  | 2.12d | 2025-06-05 A | 2025-06-10 |  | 29% | 1.5d | 2025-06-02 | 2025-06-04 | 2.5d | 1.38d |  |  | 51h | 23h | 2,257.5 | 2,670 | 1,107.5 |
| 16 | 4.1 | Uitgraven van de zwembad zone |  | 0.62d | 2025-06-05 A | 2025-06-05 A | 4 | 100% |  | 2025-06-02 | 2025-06-03 | 1d |  |  | Arbeiders [300%]; Graafmachine; Werfleider | 23h | 23h | 1,107.5 | 1,520 | 1,107.5 |
| 17 | 4.2 | Afvoeren van de aarde |  | 1d | 2025-06-05 | 2025-06-06 | 16 |  |  | 2025-06-03 | 2025-06-04 | 1d | 1.38d | 0d | Arbeiders [200%] | 16h |  | 400 | 400 |  |
| 18 | 4.3 | Uitgraven ivm technische ruimte |  | 0.5d | 2025-06-06 | 2025-06-10 | 17 |  |  | 2025-06-04 | 2025-06-04 | 0.5d | 1.38d |  | Arbeiders [200%]; Graafmachine | 12h |  | 750 | 750 |  |
| 19 | 5 | **Werkvloer** |  | 1d | 2025-06-11 | 2025-06-12 | 15, 11 |  |  | 2025-06-05 | 2025-06-05 | 1d | 0d |  |  | 56h |  | 1,600 | 1,600 |  |
| 20 | 5.1 | Afvoerbuizen plaatsen |  | 1d | 2025-06-11 | 2025-06-12 |  |  |  | 2025-06-05 | 2025-06-05 | 1d | 17d |  | Arbeiders [200%] | 16h |  | 400 | 400 |  |
| 21 | 5.2 | Dichtingen uitvoeren |  | 1d | 2025-06-11 | 2025-06-12 |  |  |  | 2025-06-05 | 2025-06-05 | 1d | 17d |  | Arbeiders [200%] | 16h |  | 400 | 400 |  |
| 22 | 5.3 | Beton gieten |  | 1d | 2025-06-11 | 2025-06-12 |  |  |  | 2025-06-05 | 2025-06-05 | 1d | 0d |  | Arbeiders [300%]; Beton [5 m³] | 24h |  | 800 | 800 |  |
| 23 | 6 | **Installatie van het zwembad** |  | 12.5d | 2025-06-13 | 2025-07-01 |  |  |  | 2025-06-10 | 2025-06-30 | 14.5d | 0d |  | Andere materialen [0.1%] | 88h |  | 18,000 | 18,000 |  |
| 24 | 6.1 | Bekisting aanbrengen |  | 2d | 2025-06-13 | 2025-06-17 | 22FS+1d |  |  | 2025-06-10 | 2025-06-11 | 2d | 0d |  | Arbeiders [250%] | 40h |  | 1,000 | 1,000 |  |
| 25 | 6.2 | Betonneren |  | 2d | 2025-06-17 | 2025-06-19 | 24 |  |  | 2025-06-12 | 2025-06-13 | 2d | 0d |  | Arbeiders [300%]; Beton [1.25 m³] | 48h |  | 2,000 | 2,000 |  |
| 26 | 6.3 | Ontkisten |  | 1.5d | 2025-06-19 | 2025-06-20 | 25 |  |  | 2025-06-16 | 2025-06-17 | 1.5d | 0d |  |  |  |  |  |  |  |
| 27 | 6.4 | Poolhouse plaatsen |  | 2d | 2025-06-17 | 2025-06-19 | 25SS |  |  | 2025-06-12 | 2025-06-13 | 2d | 8d | 0d |  |  |  |  |  |  |
| 28 | 6.5 | Pompen en leidingen installeren |  | 4d | 2025-06-19 | 2025-06-25 | 27 |  |  | 2025-06-16 | 2025-06-19 | 4d | 8d |  | Loodgieter [0.1%] |  |  | 5,000 | 5,000 |  |
| 29 | 6.6 | Tegels plaatsen |  | 2d | 2025-06-30 | 2025-07-01 | 26FS+1w |  |  | 2025-06-24 | 2025-06-30 | 4d | 0d |  |  |  |  |  |  |  |

Notes:
- 5: zou een vb kunnen zijn van manuele taak
- 8: Volledige kost voor architect
- 19: vb van links tussen overzichtstaken
- 22: Droogtijd 1d extra
- 25: gelijk begin

| ID | WBS | Task | Type | Duration | Start | Finish | Predecessors | Baseline start | Baseline finish | Baseline duration | Total slack | Deadline |
| --- | --- | --- | --- | --- | --- | --- | --- | --- | --- | --- | --- | --- |
| 30 | 7 | **Afwerken** |  | 3.5d | 2025-07-02 | 2025-07-07 |  | 2025-06-30 | 2025-07-03 | 3.5d | 0d |  |
| 31 | 7.1 | Voegen |  | 1.5d | 2025-07-02 | 2025-07-03 | 29 | 2025-06-30 | 2025-07-01 | 1.5d | 0d |  |
| 32 | 7.2 | Aanvullingen rond zwembad |  | 1d | 2025-07-03 | 2025-07-04 | 31 | 2025-07-02 | 2025-07-02 | 1d | 1d |  |
| 33 | 7.3 | graszoden plaatsen |  | 1d | 2025-07-03 | 2025-07-04 | 31 | 2025-07-02 | 2025-07-02 | 1d | 1d |  |
| 34 | 7.4 | Vullen met water |  | 1d | 2025-07-03 | 2025-07-04 | 31 | 2025-07-02 | 2025-07-02 | 1d | 0d |  |
| 35 | 7.5 | Testen |  | 1d | 2025-07-04 | 2025-07-07 | 34 | 2025-07-03 | 2025-07-03 | 1d | 0d |  |
| 36 | 8 | Oplevering | milestone | 0d | 2025-07-07 | 2025-07-07 | 35 | 2025-07-03 | 2025-07-03 | 0d | 0d | 2025-07-11 |
